# neujahrsparty2_bis

Schedule from MS Project, 2005-10-31 to 2006-01-02, status date 2005-08-31.
ETH Zurich

## Calendars

- Standard: Mon-Fri 08:00-12:00, 13:00-17:00; Sat-Sun off.

## Resources

| Resource | Rate | Cost per use |
| --- | --- | --- |
| OK Chef | 20 |  |
| OK | 10 |  |
| Catering Service | 120 | 80 |
| Deko Team | 10 |  |
| Designer | 90 |  |
| Marketingchef | 20 |  |
| Marketingteam | 10 |  |
| Druckerei | 120 | 500 |
| Barchef | 20 |  |
| Barteam | 10 |  |
| WC Firma | 70 |  |
| Security | 80 |  |
| Band |  | 500 |
| Elektriker | 70 |  |
| Partyelemente Lieferant | 80 |  |
| DJ |  | 500 |
| Feuerpolizei |  | 200 |
| Sound and Light GmbH | 150 |  |
| Besitzer |  |  |

## Schedule

| ID | WBS | Task | Type | Duration | Start | Finish | Predecessors | Total slack | Free slack | Constraint | Work |
| --- | --- | --- | --- | --- | --- | --- | --- | --- | --- | --- | --- |
| 1 | 1 | **Neujahrs-Party** |  | 46d? | 2005-10-31 | 2006-01-02 |  | 0d |  |  | 609h |
| 2 | 1.1 | **Externe Meilensteine** |  | 0d | 2005-12-28 | 2005-12-28 |  | 0d |  |  |  |
| 3 | 1.1.1 | Hangarübergabe | milestone | 0d | 2005-12-28 | 2005-12-28 |  | 0d |  | start no earlier than 2005-12-28 |  |
| 4 | 1.2 | **Generelle Vorbereitung** |  | 6d? | 2005-10-31 | 2005-11-07 |  | 14.25d |  |  | 7h |
| 5 | 1.2.1 | OK zusammenstellen |  | 1d? | 2005-10-31 | 2005-10-31 |  | 14.25d | 0d |  | 5h |
| 6 | 1.2.2 | Vertrag mit Lokalbesitzer besiegeln |  | 1d? | 2005-10-31 | 2005-10-31 |  | 19.25d | 5d |  | 2h |
| 7 | 1.2.3 | Generelle Vorbereitungen abgeschlossen | milestone | 0d | 2005-11-07 | 2005-11-07 | 5FS+5d, 6 | 14.25d | 0d |  |  |
| 8 | 1.3 | **Catering** |  | 37d? | 2005-11-08 | 2005-12-28 |  | 3d |  |  | 9h |
| 9 | 1.3.1 | Catering Service bestellen |  | 1d? | 2005-11-08 | 2005-11-08 | 7 | 35d | 32d |  | 5h |
| 10 | 1.3.2 | Catering Service aufstellen |  | 1d? | 2005-12-28 | 2005-12-28 | 9FS+2d, 3 | 3d | 0d |  | 4h |
| 11 | 1.3.3 | Catering Service bereit | milestone | 0d | 2005-12-28 | 2005-12-28 | 10 | 3d |  |  |  |
| 12 | 1.4 | **Deko-Workshop** |  | 8d? | 2005-11-08 | 2005-11-17 |  | 31d |  |  | 125h |
| 13 | 1.4.1 | Deko-Team zusammenstellen |  | 1d? | 2005-11-08 | 2005-11-08 | 7 | 31d | 0d |  | 5h |
| 14 | 1.4.2 | Erstellen von Dekorationsideen |  | 1d? | 2005-11-16 | 2005-11-16 | 13FS+5d | 31d | 0d |  | 40h |
| 15 | 1.4.3 | Bereitstellen der Dekorationen |  | 1d? | 2005-11-17 | 2005-11-17 | 14 | 31d | 0d |  | 80h |
| 16 | 1.4.4 | Deko-Workshop abgeschlossen | milestone | 0d | 2005-11-17 | 2005-11-17 | 15 | 31d |  |  |  |
| 17 | 1.5 | **Marketing** |  | 21d? | 2005-11-08 | 2005-12-06 |  | 19d |  |  | 217h |
| 18 | 1.5.1 | Marketing Team zusammenstellen |  | 1d? | 2005-11-08 | 2005-11-08 | 7 | 14.25d | 0d |  | 5h |
| 19 | 1.5.2 | Erstellung eines Werbekonzepts |  | 1d? | 2005-11-09 | 2005-11-09 | 18 | 14.25d | 0d |  | 88h |
| 20 | 1.5.3 | Design Werbeflyer |  | 1d? | 2005-11-10 | 2005-11-10 | 19 | 14.25d | 0d |  | 20h |
| 21 | 1.5.4 | Design Plakate |  | 1d? | 2005-11-10 | 2005-11-10 | 19 | 14.25d | 0d |  | 20h |
| 22 | 1.5.5 | Abnahme Flyer und Plakate |  | 1d? | 2005-11-11 | 2005-11-11 | 20, 21 | 14.25d | 0d |  | 4h |
| 23 | 1.5.6 | Schaltung von Inseraten |  | 1d? | 2005-11-14 | 2005-11-14 | 22 | 15.25d | 1d |  | 5h |
| 24 | 1.5.7 | Produktion Flyer und Plakete |  | 1d? | 2005-11-14 | 2005-11-14 | 22 | 14.25d | 0d |  | 20h |
| 25 | 1.5.8 | Auflegen von Flyern |  | 1d? | 2005-11-15 | 2005-11-15 | 24 | 14.25d | 0d |  | 25h |
| 26 | 1.5.9 | Aufhaengen von Plakaten |  | 1d? | 2005-11-15 | 2005-11-15 | 24 | 14.25d | 0d |  | 30h |
| 27 | 1.5.10 | Marketing abgeschlossen | milestone | 0d | 2005-12-06 | 2005-12-06 | 25FS+15d, 23FS+15d, 26FS+15d | 19d |  |  |  |

| ID | WBS | Task | Type | Duration | Start | Finish | Predecessors | Total slack | Free slack | Work |
| --- | --- | --- | --- | --- | --- | --- | --- | --- | --- | --- |
| 28 | 1.6 | **WCs** |  | 37d? | 2005-11-08 | 2005-12-28 |  | 3d |  | 5h |
| 29 | 1.6.1 | Bestellung |  | 1d? | 2005-11-08 | 2005-11-08 | 7 | 35d | 32d | 2h |
| 30 | 1.6.2 | Aufstellen |  | 1d? | 2005-12-28 | 2005-12-28 | 29FS+2d, 3 | 3d | 0d | 3h |
| 31 | 1.6.3 | WCs betriebsbereit | milestone | 0d | 2005-12-28 | 2005-12-28 | 30 | 3d |  |  |
| 32 | 1.7 | **Security** |  | 36d? | 2005-11-08 | 2005-12-28 |  | 4d |  | 2h |
| 33 | 1.7.1 | Bestellung Security Personal |  | 1d? | 2005-11-08 | 2005-11-08 | 7 | 37d | 33d | 2h |
| 34 | 1.7.2 | Security betriebsbereit | milestone | 0d | 2005-12-28 | 2005-12-28 | 33FS+1d, 3 | 4d |  |  |
| 35 | 1.8 | **Barbetrieb** |  | 39d? | 2005-11-08 | 2005-12-30 |  | 0d |  | 95h |
| 36 | 1.8.1 | **Bar** |  | 39d? | 2005-11-08 | 2005-12-30 |  | 0d |  | 24h |
| 37 | 1.8.1.1 | Barelemente bestellen |  | 1d? | 2005-11-08 | 2005-11-08 | 7 | 29d |  | 3h |
| 38 | 1.8.1.2 | Anlieferung Barelemente |  | 1d? | 2005-12-28 | 2005-12-28 | 3, 37FS+5d | 0d |  | 2h |
| 39 | 1.8.1.3 | Elektrische Anschluesse bereitstellen |  | 1d? | 2005-12-29 | 2005-12-29 | 38 | 0d |  | 3h |
| 40 | 1.8.1.4 | Anlieferung Kuehlschraenke |  | 1d? | 2005-12-30 | 2005-12-30 | 39 | 0d |  | 1h |
| 41 | 1.8.1.5 | Dekoration anbringen |  | 1d? | 2005-12-29 | 2005-12-29 | 38 | 1d |  | 10h |
| 42 | 1.8.1.6 | Barbeleuchtung anbringen |  | 1d? | 2005-12-29 | 2005-12-29 | 38 | 1d |  | 5h |
| 43 | 1.8.1.7 | Bar abgeschlossen | milestone | 0d | 2005-12-30 | 2005-12-30 | 40, 41, 42 | 0d |  |  |
| 44 | 1.8.2 | **Getraenke** |  | 37d? | 2005-11-08 | 2005-12-28 |  | 2d |  | 8h |
| 45 | 1.8.2.1 | Alkoholausschankgenehmung einholen |  | 1d? | 2005-11-08 | 2005-11-08 | 7 | 38d |  | 1h |
| 46 | 1.8.2.2 | Getraenkeauswahl |  | 1d? | 2005-11-08 | 2005-11-08 | 7 | 31d | 0d | 4h |
| 47 | 1.8.2.3 | Getraenkebestellung |  | 1d? | 2005-11-16 | 2005-11-16 | 46FS+5d | 31d | 28d | 1h |
| 48 | 1.8.2.4 | Getraenkeanlieferung |  | 1d? | 2005-12-28 | 2005-12-28 | 3, 47 | 3d | 0d | 2h |
| 49 | 1.8.2.5 | Getraenke abgeschlossen | milestone | 0d | 2005-12-28 | 2005-12-28 | 48 | 3d | 2d |  |
| 50 | 1.8.3 | **Barpersonal** |  | 37d? | 2005-11-08 | 2005-12-28 |  | 2d |  | 12h |
| 51 | 1.8.3.1 | Aufstellen Barpersonal |  | 1d? | 2005-11-08 | 2005-11-08 | 7 | 32d | 29d | 10h |
| 52 | 1.8.3.2 | Einweisung Barpersonal + Verpflegung |  | 1d? | 2005-12-28 | 2005-12-28 | 51FS+5d, 3 | 3d | 0d | 2h |
| 53 | 1.8.3.3 | Barpersonal abgeschlossen | milestone | 0d | 2005-12-28 | 2005-12-28 | 52 | 3d | 2d |  |

| ID | WBS | Task | Type | Duration | Start | Finish | Predecessors | Total slack | Free slack | Work |
| --- | --- | --- | --- | --- | --- | --- | --- | --- | --- | --- |
| 54 | 1.8.4 | **Sitzecke** |  | 38d? | 2005-11-08 | 2005-12-29 |  | 1d |  | 51h |
| 55 | 1.8.4.1 | Organisation Tische + Stuehle |  | 1d? | 2005-12-28 | 2005-12-28 | 3, 7 | 2d | 0d | 25h |
| 56 | 1.8.4.2 | Elektrische Anschluesse bereitstellen |  | 1d? | 2005-11-08 | 2005-11-08 | 7 | 37d | 0d | 1h |
| 57 | 1.8.4.3 | Dekoration anbringen |  | 1d? | 2005-12-29 | 2005-12-29 | 55 | 2d | 0d | 10h |
| 58 | 1.8.4.4 | Beleuchtung |  | 1d? | 2005-11-09 | 2005-11-09 | 56 | 37d | 35d | 15h |
| 59 | 1.8.4.5 | Sitzecke abgeschlossen | milestone | 0d | 2005-12-29 | 2005-12-29 | 57, 58 | 2d | 1d |  |
| 60 | 1.8.5 | Barbetrieb Vorbereitung abgeschlossen | milestone | 0d | 2005-12-30 | 2005-12-30 | 43, 49, 53, 59 | 0d |  |  |
| 61 | 1.9 | **Livekonzert** |  | 39d? | 2005-11-08 | 2005-12-30 |  | 1d |  | 134h |
| 62 | 1.9.1 | **Band** |  | 37d? | 2005-11-08 | 2005-12-28 |  | 2d |  | 32h |
| 63 | 1.9.1.1 | Bands anfragen |  | 1d? | 2005-11-08 | 2005-11-08 | 7 | 25.25d | 0d | 20h |
| 64 | 1.9.1.2 | Band-Entscheid |  | 0.75d | 2005-11-23 | 2005-11-23 | 63FS+10d | 25.25d | 23.25d | 6h |
| 65 | 1.9.1.3 | Soundcheck & Verpflegung |  | 1d? | 2005-12-28 | 2005-12-28 | 3, 64 | 2d | 0d | 6h |
| 66 | 1.9.1.4 | Band abgeschlossen | milestone | 0d | 2005-12-28 | 2005-12-28 | 65 | 2d |  |  |
| 67 | 1.9.2 | **Tanzflaeche** |  | 1d? | 2005-12-28 | 2005-12-28 |  | 2d |  | 48h |
| 68 | 1.9.2.1 | Tanzflaeche beschallen |  | 1d? | 2005-12-28 | 2005-12-28 | 3 | 2d | 0d | 4h |
| 69 | 1.9.2.2 | Tanzflaeche ausleuchten |  | 1d? | 2005-12-28 | 2005-12-28 | 3 | 2d | 0d | 4h |
| 70 | 1.9.2.3 | Tanzflaeche dekorieren |  | 1d? | 2005-12-28 | 2005-12-28 | 3 | 2d | 0d | 40h |
| 71 | 1.9.2.4 | Tanzflaeche abgeschlossen | milestone | 0d | 2005-12-28 | 2005-12-28 | 68, 69, 70 | 2d |  |  |
| 72 | 1.9.3 | **Buehne** |  | 39d? | 2005-11-08 | 2005-12-30 |  | 1d |  | 54h |
| 73 | 1.9.3.1 | Buehnenelemente bestellen |  | 1d? | 2005-11-08 | 2005-11-08 | 7 | 30d | 29d | 4h |
| 74 | 1.9.3.2 | Anlieferung Buehnenelemente |  | 1d? | 2005-12-28 | 2005-12-28 | 3, 73FS+5d | 1d | 0d | 2h |
| 75 | 1.9.3.3 | Dekoration anbringen |  | 1d? | 2005-12-29 | 2005-12-29 | 74 | 1d |  | 40h |
| 76 | 1.9.3.4 | Elektrische Anschluesse bereitstellen |  | 1d? | 2005-12-28 | 2005-12-28 | 3 | 0d |  | 3h |
| 77 | 1.9.3.5 | Buehnenbeleuchtung |  | 1d? | 2005-12-29 | 2005-12-29 | 76 | 2d |  | 2h |
| 78 | 1.9.3.6 | Soundsystem installieren |  | 1d? | 2005-12-29 | 2005-12-29 | 76 | 0d |  | 2h |
| 79 | 1.9.3.7 | Soundsystem checken |  | 1d? | 2005-12-30 | 2005-12-30 | 78 | 0d |  | 1h |
| 80 | 1.9.3.8 | Buehne abgeschlossen | milestone | 0d | 2005-12-30 | 2005-12-30 | 79, 75 | 0d |  |  |
| 81 | 1.9.4 | Livekonzert Vorbereitung abgeschlossen | milestone | 0d | 2005-12-30 | 2005-12-30 | 66, 71, 80 | 0d |  |  |

| ID | WBS | Task | Type | Duration | Start | Finish | Predecessors | Total slack | Free slack | Work |
| --- | --- | --- | --- | --- | --- | --- | --- | --- | --- | --- |
| 82 | 1.10 | **Retortenmusik** |  | 37d? | 2005-11-08 | 2005-12-28 |  | 2d |  | 9h |
| 83 | 1.10.1 | Anmeldung bei Suisa |  | 1d? | 2005-11-08 | 2005-11-08 | 7 | 37d | 0d | 1h |
| 84 | 1.10.2 | Suisa Bewilligung eingetroffen | milestone | 0d | 2005-11-08 | 2005-11-08 | 83 | 37d | 35d |  |
| 85 | 1.10.3 | Engagierung DJ |  | 1d? | 2005-11-08 | 2005-11-08 | 7 | 36d | 34d | 6h |
| 86 | 1.10.4 | Soundcheck |  | 1d? | 2005-12-28 | 2005-12-28 | 3, 85 | 2d | 0d | 2h |
| 87 | 1.10.5 | Retortenmusik Vorbereitung abgeschlossen | milestone | 0d | 2005-12-28 | 2005-12-28 | 86, 84 | 2d |  |  |
| 88 | 1.11 | **Abnahmen** |  | 1d? | 2006-01-02 | 2006-01-02 |  | 0d |  | 6h |
| 89 | 1.11.1 | Feuerpolizeiliche Abnahme |  | 1d? | 2006-01-02 | 2006-01-02 | 3, 81, 87, 60 | 0d |  | 4h |
| 90 | 1.11.2 | Abnahme durch Lokalbesitzer |  | 1d? | 2006-01-02 | 2006-01-02 | 3, 81, 87, 60 | 0d |  | 2h |
| 91 | 1.11.3 | Abnahme abgeschlossen | milestone | 0d | 2006-01-02 | 2006-01-02 | 90 | 0d |  |  |
| 92 | 1.12 | Party kann steigen | milestone | 0d | 2006-01-02 | 2006-01-02 | 91, 27 | 0d |  |  |
| 93 | 1.13 | Ferien |  | 1d? | 2005-10-31 | 2005-10-31 |  | 44d |  |  |
