# neujahrsparty3_manual_abgleich

Schedule from MS Project, 2005-10-31 to 2006-01-03, status date 2005-08-31, costs in SFr..
ETH Zurich

## Calendars

- Standard: Mon-Fri 08:00-12:00, 13:00-17:00; Sat-Sun off.

## Resources

| Resource | Rate | Cost per use |
| --- | --- | --- |
| OK Chef | 20 |  |
| OK | 10 |  |
| Catering Service | 120 | 80 |
| Deko Team | 10 |  |
| Designer | 90 |  |
| Marketingchef | 20 |  |
| Marketingteam | 10 |  |
| Druckerei | 120 | 500 |
| Barchef | 20 |  |
| Barteam | 10 |  |
| WC Firma | 70 |  |
| Security | 80 |  |
| Band |  | 500 |
| Elektriker | 70 |  |
| Partyelemente Lieferant | 80 |  |
| DJ |  | 500 |
| Feuerpolizei |  | 200 |
| Sound and Light GmbH | 150 |  |
| Besitzer |  |  |

## Schedule

| ID | WBS | Task | Type | Duration | Start | Finish | Predecessors | Total slack | Free slack | Constraint | Resources | Work | Cost |
| --- | --- | --- | --- | --- | --- | --- | --- | --- | --- | --- | --- | --- | --- |
| 1 | 1 | **Neujahrs-Party** |  | 45.25d? | 2005-10-31 17:00 | 2006-01-03 10:00 |  | 0d |  |  |  | 609h | 17,520 |
| 2 | 1.1 | **Externe Meilensteine** |  | 0d | 2005-12-28 08:00 | 2005-12-28 08:00 |  | 0.75d |  |  |  |  |  |
| 3 | 1.1.1 | Hangarübergabe | milestone | 0d | 2005-12-28 08:00 | 2005-12-28 08:00 |  | 0.75d | 0d | start no earlier than 2005-12-28 08:00 |  |  |  |
| 4 | 1.2 | **Generelle Vorbereitung** |  | 7d? | 2005-10-31 17:00 | 2005-11-09 17:00 |  | 5d |  |  |  | 7h | 140 |
| 5 | 1.2.1 | OK zusammenstellen |  | 2.5d? | 2005-10-31 17:00 | 2005-11-02 21:00 |  | 4d | 0d |  | OK Chef [25%] | 5h | 100 |
| 6 | 1.2.2 | Vertrag mit Lokalbesitzer besiegeln |  | 0.25d? | 2005-10-31 17:00 | 2005-10-31 19:00 |  | 11d | 7d |  | OK Chef | 2h | 40 |
| 7 | 1.2.3 | Generelle Vorbereitungen abgeschlossen | milestone | 0d | 2005-11-09 17:00 | 2005-11-09 17:00 | 5FS+5d, 6 | 4d | 0d |  |  |  |  |
| 8 | 1.3 | **Catering** |  | 34.5d? | 2005-11-09 17:00 | 2005-12-28 12:00 |  | 1.5d |  |  |  | 9h | 610 |
| 9 | 1.3.1 | Catering Service bestellen |  | 0.62d? | 2005-11-09 17:00 | 2005-11-09 22:00 | 7 | 32d | 31d |  | OK | 5h | 50 |
| 10 | 1.3.2 | Catering Service aufstellen |  | 0.5d? | 2005-12-28 08:00 | 2005-12-28 12:00 | 9FS+2d, 3 | 1.5d | 0d |  | Catering Service | 4h | 560 |
| 11 | 1.3.3 | Catering Service bereit | milestone | 0d | 2005-12-28 12:00 | 2005-12-28 12:00 | 10 | 1.5d |  |  |  |  |  |
| 12 | 1.4 | **Deko-Workshop** |  | 9d? | 2005-11-09 17:00 | 2005-11-23 01:00 |  | 26d |  |  |  | 125h | 1,250 |
| 13 | 1.4.1 | Deko-Team zusammenstellen |  | 2.5d? | 2005-11-09 17:00 | 2005-11-11 21:00 | 7 | 25d | 0d |  | OK [25%] | 5h | 50 |
| 14 | 1.4.2 | Erstellen von Dekorationsideen |  | 1d? | 2005-11-18 17:00 | 2005-11-21 01:00 | 13FS+5d | 25d | 1d |  | Deko Team [500%] | 40h | 400 |
| 15 | 1.4.3 | Bereitstellen der Dekorationen |  | 2d? | 2005-11-21 17:00 | 2005-11-23 01:00 | 14 | 25d | 0d |  | Deko Team [500%] | 80h | 800 |
| 16 | 1.4.4 | Deko-Workshop abgeschlossen | milestone | 0d | 2005-11-23 01:00 | 2005-11-23 01:00 | 15 | 26d |  |  |  |  |  |
| 17 | 1.5 | **Marketing** |  | 31d? | 2005-11-09 17:00 | 2005-12-22 17:00 |  | 5d |  |  |  | 217h | 8,190 |
| 18 | 1.5.1 | Marketing Team zusammenstellen |  | 2.5d? | 2005-11-09 17:00 | 2005-11-11 21:00 | 7 | 4d | 0d |  | OK [25%] | 5h | 50 |
| 19 | 1.5.2 | Erstellung eines Werbekonzepts |  | 2d? | 2005-11-18 17:00 | 2005-11-22 01:00 | 18FS+5d | 4d | 0d |  | Marketingteam [500%]; Marketingchef | 88h | 960 |
| 20 | 1.5.3 | Design Werbeflyer |  | 5d? | 2005-11-22 08:00 | 2005-11-28 17:00 | 19 | 4d | 0d |  | Designer [50%] | 20h | 1,800 |
| 21 | 1.5.4 | Design Plakate |  | 5d? | 2005-11-22 08:00 | 2005-11-28 17:00 | 19 | 4d | 0d |  | Designer [50%] | 20h | 1,800 |
| 22 | 1.5.5 | Abnahme Flyer und Plakate |  | 0.25d? | 2005-11-28 17:00 | 2005-11-28 19:00 | 20, 21 | 4d | 0d |  | OK Chef; Marketingchef | 4h | 80 |
| 23 | 1.5.6 | Schaltung von Inseraten |  | 0.62d? | 2005-11-28 19:00 | 2005-11-29 00:00 | 22 | 7d | 3d |  | OK | 5h | 50 |
| 24 | 1.5.7 | Produktion Flyer und Plakete |  | 2.5d? | 2005-11-29 08:00 | 2005-12-01 12:00 | 22 | 4.5d | 0.5d |  | Druckerei | 20h | 2,900 |
| 25 | 1.5.8 | Auflegen von Flyern |  | 0.62d? | 2005-12-01 17:00 | 2005-12-01 22:00 | 24 | 4d | 0d |  | Marketingteam [500%] | 25h | 250 |
| 26 | 1.5.9 | Aufhaengen von Plakaten |  | 0.75d? | 2005-12-01 17:00 | 2005-12-01 23:00 | 24 | 4d | 0d |  | Marketingteam [500%] | 30h | 300 |
| 27 | 1.5.10 | Marketing abgeschlossen | milestone | 0d | 2005-12-22 17:00 | 2005-12-22 17:00 | 25FS+15d, 23FS+15d, 26FS+15d | 4d |  |  |  |  |  |

| ID | WBS | Task | Type | Duration | Start | Finish | Predecessors | Total slack | Free slack | Resources | Work | Cost |
| --- | --- | --- | --- | --- | --- | --- | --- | --- | --- | --- | --- | --- |
| 28 | 1.6 | **WCs** |  | 34.38d? | 2005-11-09 17:00 | 2005-12-28 11:00 |  | 1.62d |  |  | 5h | 230 |
| 29 | 1.6.1 | Bestellung |  | 0.25d? | 2005-11-09 17:00 | 2005-11-09 19:00 | 7 | 32d | 31d | OK | 2h | 20 |
| 30 | 1.6.2 | Aufstellen |  | 0.38d? | 2005-12-28 08:00 | 2005-12-28 11:00 | 29FS+2d, 3 | 1.62d | 0d | WC Firma | 3h | 210 |
| 31 | 1.6.3 | WCs betriebsbereit | milestone | 0d | 2005-12-28 11:00 | 2005-12-28 11:00 | 30 | 1.62d |  |  |  |  |
| 32 | 1.7 | **Security** |  | 34d? | 2005-11-09 17:00 | 2005-12-28 08:00 |  | 2d |  |  | 2h | 20 |
| 33 | 1.7.1 | Bestellung Security Personal |  | 0.25d? | 2005-11-09 17:00 | 2005-11-09 19:00 | 7 | 34d | 32d | OK | 2h | 20 |
| 34 | 1.7.2 | Security betriebsbereit | milestone | 0d | 2005-12-28 08:00 | 2005-12-28 08:00 | 33FS+1d, 3 | 2d |  |  |  |  |
| 35 | 1.8 | **Barbetrieb** |  | 36d? | 2005-11-09 17:00 | 2005-12-29 22:00 |  | 2d |  |  | 95h | 1,700 |
| 36 | 1.8.1 | **Bar** |  | 35d? | 2005-11-09 17:00 | 2005-12-28 20:00 |  | 3d |  |  | 24h | 630 |
| 37 | 1.8.1.1 | Barelemente bestellen |  | 0.38d? | 2005-11-09 17:00 | 2005-11-09 20:00 | 7 | 28d |  | OK | 3h | 30 |
| 38 | 1.8.1.2 | Anlieferung Barelemente |  | 0.25d? | 2005-12-28 08:00 | 2005-12-28 10:00 | 3, 37FS+5d | 0.75d | 0d | Partyelemente Lieferant | 2h | 160 |
| 39 | 1.8.1.3 | Elektrische Anschluesse bereitstellen |  | 0.38d? | 2005-12-28 10:00 | 2005-12-28 14:00 | 38 | 1d | 0d | Elektriker | 3h | 210 |
| 40 | 1.8.1.4 | Anlieferung Kuehlschraenke |  | 0.12d? | 2005-12-28 14:00 | 2005-12-28 15:00 | 39 | 1d | 0.25d | Partyelemente Lieferant | 1h | 80 |
| 41 | 1.8.1.5 | Dekoration anbringen |  | 0.25d? | 2005-12-28 17:00 | 2005-12-28 19:00 | 38 | 0d |  | Deko Team [500%] | 10h | 100 |
| 42 | 1.8.1.6 | Barbeleuchtung anbringen |  | 0.12d? | 2005-12-28 19:00 | 2005-12-28 20:00 | 38, 41 | 0d |  | Deko Team [500%] | 5h | 50 |
| 43 | 1.8.1.7 | Bar abgeschlossen | milestone | 0d | 2005-12-28 20:00 | 2005-12-28 20:00 | 40, 41, 42 | 3d | 1d |  |  |  |
| 44 | 1.8.2 | **Getraenke** |  | 34.25d? | 2005-11-09 17:00 | 2005-12-28 10:00 |  | 1.5d |  |  | 8h | 380 |
| 45 | 1.8.2.1 | Alkoholausschankgenehmung einholen |  | 0.12d? | 2005-11-09 17:00 | 2005-11-09 18:00 | 7 | 20d | 18.25d | OK | 1h | 10 |
| 46 | 1.8.2.2 | Getraenkeauswahl |  | 0.25d? | 2005-11-09 17:00 | 2005-11-09 19:00 | 7 | 34d | 0d | OK [200%] | 4h | 40 |
| 47 | 1.8.2.3 | Getraenkebestellung |  | 0.12d? | 2005-11-09 19:00 | 2005-11-09 20:00 | 46 | 34d | 33d | OK | 1h | 10 |
| 48 | 1.8.2.4 | Getraenkeanlieferung |  | 0.25d? | 2005-12-28 08:00 | 2005-12-28 10:00 | 3, 47 | 1.75d | 0d | Catering Service | 2h | 320 |
| 49 | 1.8.2.5 | Getraenke abgeschlossen | milestone | 0d | 2005-12-28 10:00 | 2005-12-28 10:00 | 48, 45FS+15d | 1.75d | 0.75d |  |  |  |
| 50 | 1.8.3 | **Barpersonal** |  | 35d? | 2005-11-09 17:00 | 2005-12-28 19:00 |  | 0.75d |  |  | 12h | 120 |
| 51 | 1.8.3.1 | Aufstellen Barpersonal |  | 1.25d? | 2005-11-09 17:00 | 2005-11-10 19:00 | 7 | 29d | 28d | OK | 10h | 100 |
| 52 | 1.8.3.2 | Einweisung Barpersonal + Verpflegung |  | 0.25d? | 2005-12-28 17:00 | 2005-12-28 19:00 | 51FS+5d, 3 | 3d | 0d | OK | 2h | 20 |
| 53 | 1.8.3.3 | Barpersonal abgeschlossen | milestone | 0d | 2005-12-28 19:00 | 2005-12-28 19:00 | 52 | 1d | 0d |  |  |  |

| ID | WBS | Task | Type | Duration | Start | Finish | Predecessors | Total slack | Free slack | Resources | Work | Cost |
| --- | --- | --- | --- | --- | --- | --- | --- | --- | --- | --- | --- | --- |
| 54 | 1.8.4 | **Sitzecke** |  | 2d? | 2005-12-28 08:00 | 2005-12-29 22:00 |  | 1d |  |  | 51h | 570 |
| 55 | 1.8.4.1 | Organisation Tische + Stuehle |  | 0.62d? | 2005-12-28 20:00 | 2005-12-29 01:00 | 3, 7, 42 | 0d |  | Deko Team [500%] | 25h | 250 |
| 56 | 1.8.4.2 | Elektrische Anschluesse bereitstellen |  | 0.12d? | 2005-12-28 08:00 | 2005-12-28 09:00 | 7, 3 | 0.88d |  | Elektriker | 1h | 70 |
| 57 | 1.8.4.3 | Dekoration anbringen |  | 0.25d? | 2005-12-29 17:00 | 2005-12-29 19:00 | 55 | 0d |  | Deko Team [500%] | 10h | 100 |
| 58 | 1.8.4.4 | Beleuchtung |  | 0.38d? | 2005-12-29 19:00 | 2005-12-29 22:00 | 56, 57 | 0d |  | Deko Team [500%] | 15h | 150 |
| 59 | 1.8.4.5 | Sitzecke abgeschlossen | milestone | 0d | 2005-12-29 22:00 | 2005-12-29 22:00 | 57, 58 | 2d | 0d |  |  |  |
| 60 | 1.8.5 | Barbetrieb Vorbereitung abgeschlossen | milestone | 0d | 2005-12-29 22:00 | 2005-12-29 22:00 | 43, 49, 53, 59 | 2d |  |  |  |  |
| 61 | 1.9 | **Livekonzert** |  | 38d? | 2005-11-09 17:00 | 2006-01-02 22:00 |  | 0.25d |  |  | 134h | 4,400 |
| 62 | 1.9.1 | **Band** |  | 35d? | 2005-11-09 17:00 | 2005-12-28 20:00 |  | 0.75d |  |  | 32h | 1,240 |
| 63 | 1.9.1.1 | Bands anfragen |  | 1.25d? | 2005-11-09 17:00 | 2005-11-10 19:00 | 7 | 23d | 0d | OK [200%] | 20h | 200 |
| 64 | 1.9.1.2 | Band-Entscheid |  | 0.12d | 2005-11-24 17:00 | 2005-11-24 18:00 | 63FS+10d | 23d | 22d | OK [500%]; OK Chef | 6h | 70 |
| 65 | 1.9.1.3 | Soundcheck & Verpflegung |  | 0.62d? | 2005-12-28 08:00 | 2005-12-28 20:00 | 3, 64 | 0.75d | 0d | Band; Catering Service; Sound and Light GmbH | 6h | 970 |
| 66 | 1.9.1.4 | Band abgeschlossen | milestone | 0d | 2005-12-28 20:00 | 2005-12-28 20:00 | 65 | 0.75d | 0d |  |  |  |
| 67 | 1.9.2 | **Tanzflaeche** |  | 3d? | 2005-12-28 08:00 | 2005-12-30 22:00 |  | 1d |  |  | 48h | 1,600 |
| 68 | 1.9.2.1 | Tanzflaeche beschallen |  | 0.5d? | 2005-12-28 08:00 | 2005-12-28 12:00 | 3 | 1.25d | 0.5d | Sound and Light GmbH | 4h | 600 |
| 69 | 1.9.2.2 | Tanzflaeche ausleuchten |  | 0.5d? | 2005-12-28 08:00 | 2005-12-28 12:00 | 3 | 1.25d | 0.5d | Sound and Light GmbH | 4h | 600 |
| 70 | 1.9.2.3 | Tanzflaeche dekorieren |  | 1d? | 2005-12-29 22:00 | 2005-12-30 22:00 | 3, 58 | 0d |  | Deko Team [500%] | 40h | 400 |
| 71 | 1.9.2.4 | Tanzflaeche abgeschlossen | milestone | 0d | 2005-12-30 22:00 | 2005-12-30 22:00 | 68, 69, 70 | 1d |  |  |  |  |
| 72 | 1.9.3 | **Buehne** |  | 38d? | 2005-11-09 17:00 | 2006-01-02 22:00 |  | 0.25d |  |  | 54h | 1,560 |
| 73 | 1.9.3.1 | Buehnenelemente bestellen |  | 0.5d? | 2005-11-09 17:00 | 2005-11-09 21:00 | 7 | 28d |  | OK | 4h | 40 |
| 74 | 1.9.3.2 | Anlieferung Buehnenelemente |  | 0.25d? | 2005-12-28 08:00 | 2005-12-28 10:00 | 3, 73FS+5d | 0.75d |  | Partyelemente Lieferant | 2h | 160 |
| 75 | 1.9.3.3 | Dekoration anbringen |  | 1d? | 2005-12-30 22:00 | 2006-01-02 22:00 | 74, 70 | 0d |  | Deko Team [500%] | 40h | 400 |
| 76 | 1.9.3.4 | Elektrische Anschluesse bereitstellen |  | 0.38d? | 2005-12-28 08:00 | 2005-12-28 11:00 | 3 | 1d | 0d | Elektriker | 3h | 210 |
| 77 | 1.9.3.5 | Buehnenbeleuchtung |  | 0.25d? | 2005-12-28 11:00 | 2005-12-28 14:00 | 76 | 1.38d |  | Sound and Light GmbH | 2h | 300 |
| 78 | 1.9.3.6 | Soundsystem installieren |  | 0.25d? | 2005-12-28 11:00 | 2005-12-28 14:00 | 76 | 1d | 0d | Sound and Light GmbH | 2h | 300 |
| 79 | 1.9.3.7 | Soundsystem checken |  | 0.12d? | 2005-12-28 14:00 | 2005-12-28 15:00 | 78 | 1d | 0.25d | Sound and Light GmbH | 1h | 150 |
| 80 | 1.9.3.8 | Buehne abgeschlossen | milestone | 0d | 2006-01-02 22:00 | 2006-01-02 22:00 | 79, 75 | 0d |  |  |  |  |
| 81 | 1.9.4 | Livekonzert Vorbereitung abgeschlossen | milestone | 0d | 2006-01-02 22:00 | 2006-01-02 22:00 | 66, 71, 80 | 0d |  |  |  |  |

| ID | WBS | Task | Type | Duration | Start | Finish | Predecessors | Total slack | Free slack | Resources | Work | Cost |
| --- | --- | --- | --- | --- | --- | --- | --- | --- | --- | --- | --- | --- |
| 82 | 1.10 | **Retortenmusik** |  | 35d? | 2005-11-09 17:00 | 2005-12-28 18:00 |  | 0.75d |  |  | 9h | 720 |
| 83 | 1.10.1 | Anmeldung bei Suisa |  | 0.12d? | 2005-11-09 17:00 | 2005-11-09 18:00 | 7 | 34d | 0d | OK | 1h | 10 |
| 84 | 1.10.2 | Suisa Bewilligung eingetroffen | milestone | 0d | 2005-11-09 18:00 | 2005-11-09 18:00 | 83 | 34.75d | 34d |  |  |  |
| 85 | 1.10.3 | Engagierung DJ |  | 0.38d? | 2005-11-09 17:00 | 2005-11-09 20:00 | 7 | 34d | 33d | OK [200%] | 6h | 60 |
| 86 | 1.10.4 | Soundcheck |  | 0.25d? | 2005-12-28 08:00 | 2005-12-28 18:00 | 3, 85 | 0.75d | 0d | DJ; Sound and Light GmbH | 2h | 650 |
| 87 | 1.10.5 | Retortenmusik Vorbereitung abgeschlossen | milestone | 0d | 2005-12-28 18:00 | 2005-12-28 18:00 | 86, 84 | 0.75d | 0d |  |  |  |
| 88 | 1.11 | **Abnahmen** |  | 0.25d? | 2006-01-02 22:00 | 2006-01-03 10:00 |  | 0d |  |  | 6h | 260 |
| 89 | 1.11.1 | Feuerpolizeiliche Abnahme |  | 0.5d? | 2006-01-02 22:00 | 2006-01-03 10:00 | 3, 81, 87, 60 | 0d |  | OK Chef; Feuerpolizei | 4h | 240 |
| 90 | 1.11.2 | Abnahme durch Lokalbesitzer |  | 0.25d? | 2006-01-02 22:00 | 2006-01-03 09:00 | 3, 81, 87, 60 | 0d |  | OK Chef; Besitzer | 2h | 20 |
| 91 | 1.11.3 | Abnahme abgeschlossen | milestone | 0d | 2006-01-03 09:00 | 2006-01-03 09:00 | 90 | 0.12d | 0d |  |  |  |
| 92 | 1.12 | Party kann steigen | milestone | 0d | 2006-01-03 09:00 | 2006-01-03 09:00 | 91, 27 | 0.12d |  |  |  |  |
| 93 | 2 | Ferien |  | 1d? | 2005-10-31 08:00 | 2005-10-31 17:00 |  | 42d |  |  |  |  |
